Schedule from MS Project, 2007-04-02 to 2007-11-01.

## Calendars

- Standard: Mon-Fri 08:00-12:00, 13:00-17:00; Sat-Sun off.

## Resources

| Resource |
| --- |
| Offices |
| IB_IPC |
| IB_IT |
| EPO_MCD |

## Schedule

| ID | WBS | Task | Type | Duration | Start | Finish | Predecessors | Total slack | Free slack | Constraint | Resources | Work |
| --- | --- | --- | --- | --- | --- | --- | --- | --- | --- | --- | --- | --- |
| 1 | 1 | **IT support and Staff matters** |  | 58d? | 2007-04-02 | 2007-06-20 |  | 96d |  |  |  |  |
| 2 | 1.1 | **Admin assistance operational** |  | 5d | 2007-04-02 | 2007-04-06 |  | 144d | 0d |  |  |  |
| 3 | 1.1.1 | train assist |  | 5d | 2007-04-02 | 2007-04-06 |  | 37d |  |  |  |  |
| 4 | 1.2 | **IT support EN+FR operational** |  | 24d? | 2007-05-02 | 2007-06-04 |  | 108d |  |  |  |  |
| 5 | 1.2.1 | IT operations EN+FR appointed | milestone | 1d? | 2007-05-02 | 2007-05-02 |  | 136d | 0d | start no earlier than 2007-05-02 |  |  |
| 6 | 1.2.2 | training IT operation EN+FR |  | 23d | 2007-05-03 | 2007-06-04 | 5 | 136d |  |  |  |  |
| 7 | 1.3 | **IT support ES operational** |  | 36d? | 2007-05-02 | 2007-06-20 |  | 96d |  |  |  |  |
| 8 | 1.3.1 | IT operations ES appointed | milestone | 1d? | 2007-05-02 | 2007-05-02 |  | 54d | 0d | start no earlier than 2007-05-02 |  |  |
| 9 | 1.3.2 | training IT operations & IPCA6TRANS |  | 35d | 2007-05-03 | 2007-06-20 | 8 | 54d |  |  |  |  |
| 10 | 2 | **Outsource RIPCIS operations** |  | 5d | 2007-04-09 | 2007-04-13 |  | 144d |  |  |  |  |
| 11 | 2.1 | Scope of work Arcanum |  | 5d | 2007-04-09 | 2007-04-13 | 2 | 202d |  |  |  |  |
| 12 | 3 | **IPC** |  | 154d? | 2007-04-02 | 2007-11-01 |  | 0d |  |  |  | 1375.2h |
| 13 | 3.1 | **IPC AL 2007 revision** |  | 154d? | 2007-04-02 | 2007-11-01 |  | 0d |  |  |  | 1375.2h |
| 14 | 3.1.1 | **IPC AL revision 200710** |  | 153d? | 2007-04-02 | 2007-10-31 |  | 1d |  |  |  | 1375.2h |
| 15 | 3.1.1.1 | Projects discussion |  | 8d | 2007-04-02 | 2007-04-11 |  | 46.5d | 7d | start no earlier than 2007-04-02 | Offices [50%]; IB_IPC [50%] | 64h |
| 16 | 3.1.1.2 | **ALS meeting and adoption (EN)** |  | 5d | 2007-04-23 | 2007-04-27 | 15 | 39.5d |  |  |  | 40h |
| 17 | 3.1.1.2.1 | Adoption of scheme and RCL by ALS |  | 5d | 2007-04-23 | 2007-04-27 |  | 39.5d | 0d | start no earlier than 2007-04-23 | Offices [50%]; IB_IPC [50%] | 40h |
| 18 | 3.1.1.3 | **Early Publication preparation** |  | 13.5d? | 2007-04-30 | 2007-05-17 | 17 | 39.5d |  |  |  | 144h |
| 19 | 3.1.1.3.1 | **First EN IPC publication preparation iteration** |  | 7d? | 2007-04-30 | 2007-05-08 |  | 39.5d |  |  |  | 72h |
| 20 | 3.1.1.3.1.1 | **Data capture in RIPCIS** |  | 3d? | 2007-04-30 | 2007-05-02 |  | 39.5d |  |  |  | 40h |
| 21 | 3.1.1.3.1.1.1 | Capture Scheme data corrections |  | 2d | 2007-04-30 | 2007-05-01 |  | 39.5d | 0d |  | IB_IPC | 16h |
| 22 | 3.1.1.3.1.1.2 | Capture RCL data corrections |  | 2d | 2007-04-30 | 2007-05-01 |  | 39.5d | 0d |  | IB_IPC | 16h |
| 23 | 3.1.1.3.1.1.3 | Run RIPCIS error checking |  | 1d? | 2007-05-02 | 2007-05-02 | 21, 22 | 39.5d | 0d |  | IB_IPC | 8h |
| 24 | 3.1.1.3.1.2 | **First EN Master file generation** |  | 3d? | 2007-05-03 | 2007-05-07 | 23 | 39.5d |  |  |  | 24h |
| 25 | 3.1.1.3.1.2.1 | Close AL revision cycle |  | 1d? | 2007-05-03 | 2007-05-03 |  | 39.5d | 0d |  | IB_IT | 8h |

| ID | WBS | Task | Type | Duration | Start | Finish | Predecessors | Total slack | Free slack | Resources | Work |
| --- | --- | --- | --- | --- | --- | --- | --- | --- | --- | --- | --- |
| 26 | 3.1.1.3.1.2.2 | **Create Master files** |  | 2d? | 2007-05-04 | 2007-05-07 | 25 | 39.5d | 0d |  | 16h |
| 27 | 3.1.1.3.1.2.2.1 | get Validity, RCL, scheme File |  | 1d? | 2007-05-04 | 2007-05-04 |  | 39.5d | 0d | IB_IT | 8h |
| 28 | 3.1.1.3.1.2.2.2 | get Scheme images catwchword, illustrations definition and compilation files |  | 1d? | 2007-05-07 | 2007-05-07 | 27 | 39.5d |  | IB_IT | 8h |
| 29 | 3.1.1.3.1.3 | **Quality Control** |  | 1d? | 2007-05-08 | 2007-05-08 | 26 | 39.5d | 0d |  | 8h |
| 30 | 3.1.1.3.1.3.1 | Run QC procedures |  | 1d? | 2007-05-08 | 2007-05-08 |  | 39.5d |  | IB_IT | 8h |
| 31 | 3.1.1.3.2 | **Second EN IPC publication preparation iteration** |  | 5.5d? | 2007-05-09 | 2007-05-16 | 29 | 39.5d |  |  | 48h |
| 32 | 3.1.1.3.2.1 | **Data corrections in RIPCIS** |  | 1d | 2007-05-09 | 2007-05-09 |  | 39.5d |  |  | 8h |
| 33 | 3.1.1.3.2.1.1 | Capture data corrections |  | 0.5d | 2007-05-09 | 2007-05-09 |  | 39.5d | 0d | IB_IPC | 4h |
| 34 | 3.1.1.3.2.1.2 | Run RIPCIS error checking |  | 0.5d | 2007-05-09 | 2007-05-09 | 33 | 184d |  | IB_IPC | 4h |
| 35 | 3.1.1.3.2.2 | **2nd Master file generation** |  | 5d? | 2007-05-09 | 2007-05-16 | 33 | 39.5d |  |  | 40h |
| 36 | 3.1.1.3.2.2.1 | redo RIPCIS publication session |  | 1d? | 2007-05-09 | 2007-05-10 |  | 39.5d | 0d | IB_IT | 8h |
| 37 | 3.1.1.3.2.2.2 | **Create Master files** |  | 2d? | 2007-05-10 | 2007-05-14 | 36 | 39.5d | 0d |  | 16h |
| 38 | 3.1.1.3.2.2.2.1 | get Validity, RCL, scheme File |  | 1d? | 2007-05-10 | 2007-05-11 |  | 39.5d | 0d | IB_IT | 8h |
| 39 | 3.1.1.3.2.2.2.2 | get Scheme images catwchword, illustrations definition and compilation files |  | 1d? | 2007-05-11 | 2007-05-14 | 38 | 39.5d |  | IB_IT | 8h |
| 40 | 3.1.1.3.2.2.3 | **Quality Control** |  | 2d? | 2007-05-14 | 2007-05-16 | 37 | 121.5d |  |  | 16h |
| 41 | 3.1.1.3.2.2.3.1 | Run QC |  | 1d? | 2007-05-14 | 2007-05-15 |  | 179.5d | 0d | IB_IT | 8h |
| 42 | 3.1.1.3.2.2.3.2 | check QC logs |  | 1d | 2007-05-15 | 2007-05-16 | 41 | 179.5d |  | IB_IPC [50%]; IB_IT [50%] | 8h |
| 43 | 3.1.1.3.3 | Early master Files ready | milestone | 1d? | 2007-05-14 | 2007-05-15 | 37 | 39.5d | 0d |  |  |
| 44 | 3.1.1.3.4 | Put early master files in IBIS |  | 1d? | 2007-05-15 | 2007-05-16 | 43 | 179.5d |  | IB_IT | 8h |
| 45 | 3.1.1.3.5 | **Internet early publication generation EN only** |  | 2d? | 2007-05-15 | 2007-05-17 | 43 | 39.5d |  |  | 16h |
| 46 | 3.1.1.3.5.1 | Data generation |  | 1d? | 2007-05-15 | 2007-05-16 |  | 39.5d | 0d | IB_IT | 8h |
| 47 | 3.1.1.3.5.2 | checking |  | 1d? | 2007-05-16 | 2007-05-17 | 46 | 39.5d | 0d | IB_IT | 8h |
| 48 | 3.1.1.4 | Early publication ready | milestone | 1d? | 2007-05-17 | 2007-05-18 | 47 | 39.5d | 0d |  |  |
| 49 | 3.1.1.5 | EN Early publication Checking by Offices |  | 10d | 2007-05-18 | 2007-06-01 | 48 | 39.5d | 0d | Offices | 80h |

| ID | WBS | Task | Type | Duration | Start | Finish | Predecessors | Total slack | Free slack | Resources | Work |
| --- | --- | --- | --- | --- | --- | --- | --- | --- | --- | --- | --- |
| 50 | 3.1.1.6 | **Final publication preparation** |  | 45d? | 2007-06-01 | 2007-08-03 | 49 | 39.5d |  |  | 351.2h |
| 51 | 3.1.1.6.1 | **Adopt FR version** |  | 31d? | 2007-06-01 | 2007-07-16 |  | 39.5d |  |  | 247.2h |
| 52 | 3.1.1.6.1.1 | Prepare FR version |  | 20d | 2007-06-01 | 2007-06-29 |  | 39.5d | 0d | Offices | 160h |
| 53 | 3.1.1.6.1.2 | **First FR+EN early publication preparation** |  | 9d? | 2007-06-29 | 2007-07-12 | 49, 52 | 39.5d | 0d |  | 71.2h |
| 54 | 3.1.1.6.1.2.1 | **Data capture in RIPCIS** |  | 5d? | 2007-06-29 | 2007-07-06 |  | 39.5d | 0d |  | 40h |
| 55 | 3.1.1.6.1.2.1.1 | Capture FR Scheme data+ EN corrections |  | 4d | 2007-06-29 | 2007-07-05 |  | 39.5d | 0d | IB_IPC | 32h |
| 56 | 3.1.1.6.1.2.1.2 | Run RIPCIS error checking |  | 1d? | 2007-07-05 | 2007-07-06 | 55 | 39.5d |  | IB_IPC | 8h |
| 57 | 3.1.1.6.1.2.2 | **First FR+EN Master file generation** |  | 2d? | 2007-07-06 | 2007-07-10 | 54 | 39.5d |  |  | 16h |
| 58 | 3.1.1.6.1.2.2.1 | Close AL revision cycle |  | 1d? | 2007-07-06 | 2007-07-09 |  | 39.5d | 0d | IB_IT | 8h |
| 59 | 3.1.1.6.1.2.2.2 | **Create Master files updates** |  | 1d? | 2007-07-09 | 2007-07-10 | 58 | 39.5d | 0d |  | 8h |
| 60 | 3.1.1.6.1.2.2.2.1 | get Schemecatwchword, definition and compilation files |  | 1d? | 2007-07-09 | 2007-07-10 |  | 39.5d |  | IB_IT | 8h |
| 61 | 3.1.1.6.1.2.3 | **Quality Control** |  | 1d | 2007-07-10 | 2007-07-11 | 58 | 39.5d |  |  | 7.2h |
| 62 | 3.1.1.6.1.2.3.1 | Run QC procedures and checking |  | 1d | 2007-07-10 | 2007-07-11 | 59 | 39.5d | 0d | IB_IT [50%]; IB_IPC [50%] | 7.2h |
| 63 | 3.1.1.6.1.2.4 | Publish master files in IBIS |  | 1d? | 2007-07-11 | 2007-07-12 | 62 | 39.5d |  | IB_IT | 8h |
| 64 | 3.1.1.6.1.3 | **Internet early publication generation FR+EN** |  | 2d? | 2007-07-12 | 2007-07-16 | 53 | 39.5d |  |  | 16h |
| 65 | 3.1.1.6.1.3.1 | Data generation |  | 1d? | 2007-07-12 | 2007-07-13 |  | 39.5d | 0d | IB_IT | 8h |
| 66 | 3.1.1.6.1.3.2 | checking |  | 1d? | 2007-07-13 | 2007-07-16 | 65 | 39.5d | 0d | IB_IPC | 8h |
| 67 | 3.1.1.6.2 | Early publication EN+FR ready | milestone | 1d? | 2007-07-16 | 2007-07-17 | 66 | 39.5d | 0d |  |  |
| 68 | 3.1.1.6.3 | EN+FR Early publication Checking |  | 5d | 2007-07-17 | 2007-07-24 | 67 | 39.5d | 0d | Offices | 40h |
| 69 | 3.1.1.6.4 | **Final FR+EN publication preparation** |  | 6d? | 2007-07-24 | 2007-08-01 | 68 | 39.5d | 0d |  | 48h |
| 70 | 3.1.1.6.4.1 | **Data capture in RIPCIS** |  | 2d? | 2007-07-24 | 2007-07-26 |  | 39.5d | 0d |  | 16h |
| 71 | 3.1.1.6.4.1.1 | Capture data corrections |  | 1d | 2007-07-24 | 2007-07-25 |  | 39.5d | 0d | IB_IPC | 8h |
| 72 | 3.1.1.6.4.1.2 | Run RIPCIS error checking |  | 1d? | 2007-07-25 | 2007-07-26 | 71 | 39.5d |  | IB_IPC | 8h |
| 73 | 3.1.1.6.4.2 | **Final FR+EN Master file generation** |  | 2d? | 2007-07-26 | 2007-07-30 | 70 | 39.5d |  |  | 16h |
| 74 | 3.1.1.6.4.2.1 | Close AL revision cycle |  | 1d? | 2007-07-26 | 2007-07-27 |  | 39.5d | 0d | IB_IT | 8h |

| ID | WBS | Task | Type | Duration | Start | Finish | Predecessors | Total slack | Free slack | Constraint | Resources | Work |
| --- | --- | --- | --- | --- | --- | --- | --- | --- | --- | --- | --- | --- |
| 75 | 3.1.1.6.4.2.2 | **Create Master files updates** |  | 1d? | 2007-07-27 | 2007-07-30 | 74 | 39.5d | 0d |  |  | 8h |
| 76 | 3.1.1.6.4.2.2.1 | get Schemecatwchword, definition and compilation files |  | 1d? | 2007-07-27 | 2007-07-30 |  | 39.5d |  |  | IB_IT | 8h |
| 77 | 3.1.1.6.4.3 | **Quality Control** |  | 1d? | 2007-07-30 | 2007-07-31 | 74 | 39.5d |  |  |  | 8h |
| 78 | 3.1.1.6.4.3.1 | Run QC procedures |  | 1d? | 2007-07-30 | 2007-07-31 | 75 | 39.5d | 0d |  | IB_IT | 8h |
| 79 | 3.1.1.6.4.4 | Publish master files inIPC offcial WEB site |  | 1d? | 2007-07-31 | 2007-08-01 | 78 | 39.5d |  |  | IB_IT | 8h |
| 80 | 3.1.1.6.5 | **Internet final publication generation FR+EN** |  | 2d? | 2007-08-01 | 2007-08-03 |  | 39.5d |  |  |  | 16h |
| 81 | 3.1.1.6.5.1 | Data generation |  | 1d? | 2007-08-01 | 2007-08-02 | 69 | 39.5d | 0d |  | IB_IT | 8h |
| 82 | 3.1.1.6.5.2 | checking |  | 1d? | 2007-08-02 | 2007-08-03 | 81 | 39.5d | 0d |  | IB_IPC | 8h |
| 83 | 3.1.1.7 | Final publication EN+FR ready | milestone | 1d? | 2007-08-03 | 2007-08-06 | 82 | 39.5d |  |  |  |  |
| 84 | 3.1.1.8 | **Reclassification** |  | 121.5d? | 2007-05-15 | 2007-10-31 | 43 | 1d |  |  |  | 696h |
| 85 | 3.1.1.8.1 | **First reclassification** |  | 121.5d? | 2007-05-15 | 2007-10-31 |  | 1d |  |  |  | 696h |
| 86 | 3.1.1.8.1.1 | create working lists |  | 10d? | 2007-05-15 | 2007-05-29 |  | 169.5d | 0d |  | EPO_MCD | 80h |
| 87 | 3.1.1.8.1.2 | publish working list on reclassification Web site |  | 1d? | 2007-05-29 | 2007-05-30 | 86 | 169.5d |  |  | IB_IT | 8h |
| 88 | 3.1.1.8.1.3 | Reclassifiy and return results to MCD |  | 53d | 2007-05-15 | 2007-07-27 |  | 104.5d | 0d |  | Offices | 424h |
| 89 | 3.1.1.8.1.4 | Check reclassification data |  | 1d? | 2007-07-27 | 2007-07-30 | 88 | 104.5d | 45.5d |  | EPO_MCD | 8h |
| 90 | 3.1.1.8.1.5 | Run reclassification in MCD |  | 1d? | 2007-10-02 | 2007-10-02 | 89, 93 | 59d | 0d |  | EPO_MCD | 8h |
| 91 | 3.1.1.8.1.6 | Checking by MCD users |  | 13d | 2007-10-03 | 2007-10-19 | 90 | 59d | 0d |  | Offices | 104h |
| 92 | 3.1.1.8.1.7 | Send MCD updates |  | 8d | 2007-10-22 | 2007-10-31 | 91 | 59d |  |  | EPO_MCD | 64h |
| 93 | 3.1.1.9 | Entry into Force | milestone | 1d? | 2007-10-01 | 2007-10-01 | 83 | 0d |  | must finish on 2007-10-01 |  |  |
| 94 | 3.1.2 | IPC AL 2007 revision 1 |  | 1d | 2007-05-01 | 2007-05-01 |  | 190d |  | start no earlier than 2007-05-01 |  |  |
| 95 | 3.1.3 | IPC AL 2007 revision 2 |  | 1d | 2007-11-01 | 2007-11-01 |  | 0d |  | start no earlier than 2007-11-01 |  |  |
